# WebSite Development

Schedule from MS Project, 2012-01-02 to 2012-02-16.
Websites
MCDLink, Inc.

## Calendars

- Standard: Mon-Fri 08:00-12:00, 13:00-17:00; Sat-Sun off.

## Resources

| Resource |
| --- |
| Management |
| Project manager |
| Analyst |
| Developer |
| Testers |
| Trainers |
| Technical communicators |
| Deployment team |
| Tech Writer |

## Schedule

| ID | WBS | Task | Type | Duration | Start | Finish | Predecessors | Total slack | Free slack | Resources | Work |
| --- | --- | --- | --- | --- | --- | --- | --- | --- | --- | --- | --- |
| 1 | 1 | **Scope** |  | 2.5d | 2012-01-02 | 2012-01-04 |  | 29d |  |  | 28h |
| 2 | 1.1 | Verify/Secure project sponsorship |  | 1d | 2012-01-02 | 2012-01-02 |  | 32.5d |  | Management | 8h |
| 3 | 1.2 | Determine project scope |  | 4h | 2012-01-02 | 2012-01-02 |  | 29d | 0d | Management | 4h |
| 4 | 1.3 | Define preliminary resources |  | 1d | 2012-01-02 | 2012-01-03 | 3 | 29d | 0d | Project manager | 8h |
| 5 | 1.4 | Secure core resources |  | 1d | 2012-01-03 | 2012-01-04 | 4 | 29d | 0d | Project manager | 8h |
| 6 | 1.5 | Scope complete | milestone | 0d | 2012-01-04 | 2012-01-04 | 5 | 29d | 0d |  |  |
| 7 | 2 | **Analysis/Website Requirements** |  | 6d? | 2012-01-02 | 2012-01-09 |  | 0d |  |  | 192h |
| 8 | 2.1 | **Conduct needs analysis** |  | 2d? | 2012-01-04 | 2012-01-06 | 6 | 29d |  | Analyst | 128h |
| 9 | 2.1.1 | **Client Workbook** |  | 2d? | 2012-01-04 | 2012-01-06 |  | 29d |  | Project manager | 32h |
| 10 | 2.1.1.1 | Client Survey |  | 1d? | 2012-01-04 | 2012-01-05 |  | 30d |  |  |  |
| 11 | 2.1.1.2 | Maintenance Survey |  | 2d | 2012-01-04 | 2012-01-06 |  | 29d |  | Project manager | 16h |
| 12 | 2.1.2 | Review Client Information |  | 2d | 2012-01-04 | 2012-01-06 |  | 29d |  | Deployment team; Project manager | 32h |
| 13 | 2.1.3 | **Client Workbook Conclusion** |  | 2d | 2012-01-04 | 2012-01-06 |  | 29d |  | Project manager | 48h |
| 14 | 2.1.3.1 | Expanded Technical Check |  | 2d | 2012-01-04 | 2012-01-06 |  | 29d |  | Project manager; Deployment team | 32h |
| 15 | 2.2 | Draft preliminary Website specifications |  | 1d | 2012-01-02 | 2012-01-02 |  | 32.5d |  | Analyst | 8h |
| 16 | 2.3 | Develop preliminary budget or time |  | 2d | 2012-01-02 | 2012-01-03 |  | 0d |  | Project manager | 16h |
| 17 | 2.4 | Review Website specifications/budget with team |  | 4h | 2012-01-04 | 2012-01-04 | 16 | 0d |  | Project manager; Analyst | 8h |
| 18 | 2.5 | Incorporate feedback on Website specifications |  | 1d | 2012-01-04 | 2012-01-05 | 17 | 0d |  | Analyst | 8h |
| 19 | 2.6 | Develop delivery timeline |  | 1d | 2012-01-05 | 2012-01-06 | 18 | 0d |  | Project manager | 8h |
| 20 | 2.7 | Obtain approvals to proceed (concept, timeline, budget) |  | 4h | 2012-01-06 | 2012-01-06 | 19 | 0d |  | Management; Project manager | 8h |
| 21 | 2.8 | Secure required resources |  | 1d | 2012-01-09 | 2012-01-09 | 20 | 0d |  | Project manager | 8h |
| 22 | 2.9 | Analysis complete | milestone | 0d | 2012-01-09 | 2012-01-09 | 21 | 0d |  |  |  |
| 23 | 3 | **Design** |  | 27.5d? | 2012-01-10 | 2012-02-16 |  | 0d |  |  | 224h |
| 24 | 3.1 | Review preliminary website specifications |  | 2d | 2012-01-10 | 2012-01-11 | 22 | 0d |  | Analyst | 16h |
| 25 | 3.2 | Develop design specifications |  | 5d | 2012-01-12 | 2012-01-18 | 24 | 0d |  | Analyst | 40h |
| 26 | 3.3 | Have Technical Writer Engage Customer on Content |  | 5d? | 2012-01-19 | 2012-01-25 | 25 | 0d |  | Tech Writer | 40h |
| 27 | 3.4 | Develop prototype based on design specifications |  | 4d | 2012-01-26 | 2012-01-31 | 26 | 0d |  | Analyst | 32h |
| 28 | 3.5 | Meta Data Build/Implementation |  | 3d | 2012-02-01 | 2012-02-03 | 27 | 0d |  | Developer | 24h |
| 29 | 3.6 | Usability Testing |  | 5d | 2012-02-06 | 2012-02-10 | 28 | 0d |  | Testers | 40h |
| 30 | 3.7 | Review design specifications |  | 2d | 2012-02-13 | 2012-02-14 | 29 | 0d |  | Management | 16h |
| 31 | 3.8 | Incorporate feedback into design specifications |  | 1d | 2012-02-15 | 2012-02-15 | 30 | 0d |  | Management | 8h |
| 32 | 3.9 | Obtain approval to proceed |  | 4h | 2012-02-16 | 2012-02-16 | 31 | 0d |  | Management; Project manager | 8h |
| 33 | 3.10 | Design complete | milestone | 0d | 2012-02-16 | 2012-02-16 | 32 | 0d |  |  |  |

| ID | WBS | Task | Type | Duration | Start | Finish | Predecessors | Total slack | Free slack | Resources | Work |
| --- | --- | --- | --- | --- | --- | --- | --- | --- | --- | --- | --- |
| 34 | 4 | **Pilot (Optional)** |  | 9d | 2012-01-10 | 2012-01-20 |  | 12.5d |  |  | 64h |
| 35 | 4.1 | Identify review group |  | 1d | 2012-01-10 | 2012-01-10 | 22 | 12.5d | 0d | Project manager | 8h |
| 36 | 4.2 | Develop Website delivery mechanism |  | 1d | 2012-01-11 | 2012-01-11 | 35 | 12.5d | 0d |  |  |
| 37 | 4.3 | Role out Website |  | 1d | 2012-01-12 | 2012-01-12 | 36 | 12.5d | 0d | Deployment team | 8h |
| 38 | 4.4 | Obtain user feedback |  | 1w | 2012-01-13 | 2012-01-19 | 37 | 12.5d | 0d | Deployment team | 40h |
| 39 | 4.5 | Evaluate review information |  | 1d | 2012-01-20 | 2012-01-20 | 38 | 12.5d | 0d | Deployment team | 8h |
| 40 | 4.6 | Pilot complete | milestone | 0d | 2012-01-20 | 2012-01-20 | 39 | 12.5d | 0d |  |  |
| 41 | 5 | **Deployment** |  | 4d | 2012-01-23 | 2012-01-26 |  | 12.5d |  |  | 32h |
| 42 | 5.1 | Determine final role out strategy |  | 1d | 2012-01-23 | 2012-01-23 | 40 | 12.5d | 0d | Deployment team | 8h |
| 43 | 5.2 | Develop role out methodology |  | 1d | 2012-01-24 | 2012-01-24 | 42 | 12.5d | 0d | Deployment team | 8h |
| 44 | 5.3 | Identify and assign owner for role out |  | 1d | 2012-01-25 | 2012-01-25 | 43 | 12.5d | 0d | Deployment team | 8h |
| 45 | 5.4 | Role out Website |  | 1d | 2012-01-26 | 2012-01-26 | 44 | 12.5d | 0d | Deployment team | 8h |
| 46 | 5.5 | Role out complete | milestone | 0d | 2012-01-26 | 2012-01-26 | 45 | 12.5d | 0d |  |  |
| 47 | 6 | **Post Implementation Review** |  | 2d | 2012-01-27 | 2012-01-30 |  | 12.5d |  |  | 16h |
| 48 | 6.1 | Document lessons learned |  | 1d | 2012-01-27 | 2012-01-27 | 46 | 12.5d | 0d | Project manager | 8h |
| 49 | 6.2 | Create Website maintenance team |  | 1d | 2012-01-30 | 2012-01-30 | 48 | 12.5d | 0d | Project manager | 8h |
| 50 | 6.3 | Post implementation review complete | milestone | 0d | 2012-01-30 | 2012-01-30 | 49 | 12.5d |  |  |  |
